# VOORBEREIDING GEVEL-DAK FASE

Schedule from MS Project, 2003-01-12 to 2003-06-12, status date 2003-01-08.
BAM Nelissen Van Egteren

## Calendars

- ALLEEN WERKDAGEN: Mon-Fri 08:30-12:30, 13:00-17:00; Sat-Sun off. Exceptions (off unless hours are given): 2003-01-11 to 2003-01-12 08:30-12:30, 13:00-17:00, 2003-01-18 to 2003-01-19 08:30-12:30, 13:00-17:00, 2003-01-25 to 2003-01-26 08:30-12:30, 13:00-17:00, 2003-02-01 to 2003-02-02 08:30-12:30, 13:00-17:00, 2003-02-08 to 2003-02-09 08:30-12:30, 13:00-17:00, 2003-02-15 to 2003-02-16 08:30-12:30, 13:00-17:00, 2003-02-22 to 2003-02-23 08:30-12:30, 13:00-17:00, 2003-03-01 to 2003-03-02 08:30-12:30, 13:00-17:00, 2003-03-08 to 2003-03-09 08:30-12:30, 13:00-17:00, 2003-03-15 to 2003-03-16 08:30-12:30, 13:00-17:00, 2003-03-22 to 2003-03-23 08:30-12:30, 13:00-17:00, 2003-03-29 to 2003-03-30 08:30-12:30, 13:00-17:00, 2003-04-05 to 2003-04-06 08:30-12:30, 13:00-17:00, 2003-04-12 to 2003-04-13 08:30-12:30, 13:00-17:00, 2003-04-19 to 2003-04-20 08:30-12:30, 13:00-17:00, 2003-04-26 to 2003-04-27 08:30-12:30, 13:00-17:00, 2003-05-03 to 2003-05-04 08:30-12:30, 13:00-17:00, 2003-05-10 to 2003-05-11 08:30-12:30, 13:00-17:00, 2003-05-17 to 2003-05-18 08:30-12:30, 13:00-17:00, 2003-05-24 to 2003-05-25 08:30-12:30, 13:00-17:00, 2003-05-31 to 2003-06-01 08:30-12:30, 13:00-17:00, 2003-06-07 to 2003-06-08 08:30-12:30, 13:00-17:00.

## Schedule

| ID | WBS | Task | Type | Duration | Start | Finish | Predecessors | Total slack | Free slack |
| --- | --- | --- | --- | --- | --- | --- | --- | --- | --- |
| 1 | 1 | **GEVEL KOZIJNEN (hout-staal)** |  | 127d | 2003-01-12 | 2003-05-18 |  | 25d |  |
| 2 | 1.1 | bestektekeningen |  | 3d | 2003-01-12 | 2003-01-14 |  | 25d | 0d |
| 3 | 1.2 | overzichtstekening kozijnen |  | 5d | 2003-01-15 | 2003-01-19 | 2 | 25d | 0d |
| 4 | 1.3 | principe details kozijnen |  | 5d | 2003-01-15 | 2003-01-19 | 3SS | 25d | 0d |
| 5 | 1.4 | **contractvorming** |  | 36d | 2003-01-20 | 2003-02-24 | 4 | 25d |  |
| 6 | 1.4.1 | prijsaanvraag opstellen |  | 5d | 2003-01-20 | 2003-01-24 |  | 25d | 0d |
| 7 | 1.4.2 | offerte aanvraag leveranciers |  | 5d | 2003-01-25 | 2003-01-29 | 6 | 25d | 0d |
| 8 | 1.4.3 | opstellen offerte door leveranciers |  | 10d | 2003-01-30 | 2003-02-08 | 7 | 25d | 0d |
| 9 | 1.4.4 | offertes leveranciers beoordelen |  | 5d | 2003-02-09 | 2003-02-13 | 8 | 25d | 0d |
| 10 | 1.4.5 | prijsonderhandeling met lev. |  | 5d | 2003-02-14 | 2003-02-18 | 9 | 25d | 0d |
| 11 | 1.4.6 | leveringscontract opstellen |  | 3d | 2003-02-19 | 2003-02-21 | 10 | 25d | 0d |
| 12 | 1.4.7 | leveringscontract tekenen |  | 3d | 2003-02-22 | 2003-02-24 | 11 | 25d | 0d |
| 13 | 1.5 | **productietekening kozijnen** |  | 33d | 2003-02-25 | 2003-03-29 |  | 25d |  |
| 14 | 1.5.1 | concept productietek.maken |  | 10d | 2003-02-25 | 2003-03-06 | 12 | 25d | 0d |
| 15 | 1.5.2 | controle tekening door partners |  | 10d | 2003-03-07 | 2003-03-16 | 14 | 25d | 0d |
| 16 | 1.5.3 | commentaar partners verwerken |  | 5d | 2003-03-17 | 2003-03-21 | 15 | 25d | 0d |
| 17 | 1.5.4 | productie.tek.definitief maken |  | 5d | 2003-03-22 | 2003-03-26 | 16 | 25d | 0d |
| 18 | 1.5.5 | productietekening goedkeuren |  | 3d | 2003-03-27 | 2003-03-29 | 17 | 25d | 0d |
| 19 | 1.6 | **productieproces kozijnen** |  | 50d | 2003-03-30 | 2003-05-18 | 18 | 25d |  |
| 20 | 1.6.1 | voorbereiding productie |  | 10d | 2003-03-30 | 2003-04-08 |  | 25d | 0d |
| 21 | 1.6.2 | produceren kozijnen |  | 40d | 2003-04-09 | 2003-05-18 | 20 | 25d | 0d |
| 22 | 1.6.3 | afroepen 1e levering kozijnen |  | 1d | 2003-04-29 | 2003-04-29 | 21SS+20d | 35d | 0d |
| 23 | 1.6.4 | start montage kozijnen | milestone | 0d | 2003-05-08 | 2003-05-08 | 22SS+10d | 35d |  |
| 25 | 2 | **ALUMINIUM GEVELPUIEN** |  | 152d | 2003-01-12 | 2003-06-12 |  | 0d |  |
| 26 | 2.1 | bestektekeningen |  | 3d | 2003-01-12 | 2003-01-14 |  | 0d |  |
| 27 | 2.2 | overzichtstekening alu gevelpuien |  | 5d | 2003-01-15 | 2003-01-19 | 26 | 0d |  |
| 28 | 2.3 | principe details alu gevelpuien |  | 5d | 2003-01-15 | 2003-01-19 | 27SS | 0d |  |

| ID | WBS | Task | Type | Duration | Start | Finish | Predecessors | Total slack | Free slack |
| --- | --- | --- | --- | --- | --- | --- | --- | --- | --- |
| 29 | 2.4 | **contractvorming** |  | 36d | 2003-01-20 | 2003-02-24 | 28 | 0d |  |
| 30 | 2.4.1 | prijsaanvraag opstellen |  | 5d | 2003-01-20 | 2003-01-24 |  | 0d |  |
| 31 | 2.4.2 | offerte aanvraag leveranciers |  | 5d | 2003-01-25 | 2003-01-29 | 30 | 0d |  |
| 32 | 2.4.3 | opstellen offerte door leveranciers |  | 10d | 2003-01-30 | 2003-02-08 | 31 | 0d |  |
| 33 | 2.4.4 | offertes leveranciers beoordelen |  | 5d | 2003-02-09 | 2003-02-13 | 32 | 0d |  |
| 34 | 2.4.5 | prijsonderhandeling met lev. |  | 5d | 2003-02-14 | 2003-02-18 | 33 | 0d |  |
| 35 | 2.4.6 | leveringscontract opstellen |  | 3d | 2003-02-19 | 2003-02-21 | 34 | 0d |  |
| 36 | 2.4.7 | leveringscontract tekenen |  | 3d | 2003-02-22 | 2003-02-24 | 35 | 0d |  |
| 37 | 2.5 | **productietekening alu puien** |  | 58d | 2003-02-25 | 2003-04-23 |  | 0d |  |
| 38 | 2.5.1 | concept productietek.maken |  | 20d | 2003-02-25 | 2003-03-16 | 36 | 0d |  |
| 39 | 2.5.2 | controle tekening door partners |  | 20d | 2003-03-07 | 2003-03-26 | 38SS+10d | 0d |  |
| 40 | 2.5.3 | commentaar partners verwerken |  | 20d | 2003-03-17 | 2003-04-05 | 39SS+10d | 0d |  |
| 41 | 2.5.4 | productie.tek.definitief maken |  | 10d | 2003-04-01 | 2003-04-10 | 40SS+15d | 0d |  |
| 42 | 2.5.5 | controle prod.tek. door partners |  | 10d | 2003-04-11 | 2003-04-20 | 41 | 0d |  |
| 43 | 2.5.6 | productietekening goedkeuren |  | 3d | 2003-04-21 | 2003-04-23 | 42 | 0d |  |
| 44 | 2.6 | **productieproces alu gevelpuien** |  | 50d | 2003-04-24 | 2003-06-12 | 43 | 0d |  |
| 45 | 2.6.1 | voorbereiding productie |  | 10d | 2003-04-24 | 2003-05-03 |  | 0d |  |
| 46 | 2.6.2 | produceren alu gevelpuien |  | 40d | 2003-05-04 | 2003-06-12 | 45 | 0d |  |
| 47 | 2.6.3 | afroepen 1e levering alu puien |  | 1d | 2003-05-24 | 2003-05-24 | 46SS+20d | 10d | 0d |
| 48 | 2.6.4 | start montage alu puien | milestone | 0d | 2003-06-02 | 2003-06-02 | 47SS+10d | 10d |  |
| 50 | 3 | **STALEN GEVEL BEPLATING** |  | 142d | 2003-01-12 | 2003-06-02 |  | 10d |  |
| 51 | 3.1 | bestektekeningen |  | 3d | 2003-01-12 | 2003-01-14 |  | 10d | 0d |
| 52 | 3.2 | overzichtstekening gevelbeplating |  | 5d | 2003-01-15 | 2003-01-19 | 51 | 10d | 0d |
| 53 | 3.3 | principe details gevelbeplating |  | 5d | 2003-01-15 | 2003-01-19 | 52SS | 10d | 0d |

| ID | WBS | Task | Type | Duration | Start | Finish | Predecessors | Total slack | Free slack |
| --- | --- | --- | --- | --- | --- | --- | --- | --- | --- |
| 54 | 3.4 | **contractvorming** |  | 36d | 2003-01-20 | 2003-02-24 | 53 | 10d |  |
| 55 | 3.4.1 | prijsaanvraag opstellen |  | 5d | 2003-01-20 | 2003-01-24 |  | 10d | 0d |
| 56 | 3.4.2 | offerte aanvraag leveranciers |  | 5d | 2003-01-25 | 2003-01-29 | 55 | 10d | 0d |
| 57 | 3.4.3 | opstellen offerte door leveranciers |  | 10d | 2003-01-30 | 2003-02-08 | 56 | 10d | 0d |
| 58 | 3.4.4 | offertes leveranciers beoordelen |  | 5d | 2003-02-09 | 2003-02-13 | 57 | 10d | 0d |
| 59 | 3.4.5 | prijsondrhandeling met lev. |  | 5d | 2003-02-14 | 2003-02-18 | 58 | 10d | 0d |
| 60 | 3.4.6 | leveringscontract opstellen |  | 3d | 2003-02-19 | 2003-02-21 | 59 | 10d | 0d |
| 61 | 3.4.7 | leveringscontract tekenen |  | 3d | 2003-02-22 | 2003-02-24 | 60 | 10d | 0d |
| 62 | 3.5 | **productietek, gevelbeplating** |  | 58d | 2003-02-25 | 2003-04-23 |  | 10d |  |
| 63 | 3.5.1 | concept productietek.maken |  | 20d | 2003-02-25 | 2003-03-16 | 61 | 10d | 0d |
| 64 | 3.5.2 | controle tekening door partners |  | 20d | 2003-03-07 | 2003-03-26 | 63SS+10d | 10d | 0d |
| 65 | 3.5.3 | commentaar partners verwerken |  | 20d | 2003-03-17 | 2003-04-05 | 64SS+10d | 10d | 0d |
| 66 | 3.5.4 | productie.tek.definitief maken |  | 10d | 2003-04-01 | 2003-04-10 | 65SS+15d | 10d | 0d |
| 67 | 3.5.5 | controle prod.tek. door partners |  | 10d | 2003-04-11 | 2003-04-20 | 66 | 10d | 0d |
| 68 | 3.5.6 | productietekening goedkeuren |  | 3d | 2003-04-21 | 2003-04-23 | 67 | 10d | 0d |
| 69 | 3.6 | **productieproces gevelbeplating** |  | 40d | 2003-04-24 | 2003-06-02 | 68 | 10d |  |
| 70 | 3.6.1 | voorbereiding productie |  | 10d | 2003-04-24 | 2003-05-03 |  | 10d | 0d |
| 71 | 3.6.2 | produceren gevelbeplating |  | 30d | 2003-05-04 | 2003-06-02 | 70 | 10d | 0d |
| 72 | 3.6.3 | afroepen 1e levering beplating |  | 1d | 2003-05-24 | 2003-05-24 | 71SS+20d | 10d | 0d |
| 73 | 3.6.4 | start montage gevelbeplating | milestone | 0d | 2003-06-02 | 2003-06-02 | 72SS+10d | 10d |  |
| 75 | 4 | **NATUURSTEEN GEVELBEPLATING** |  | 152d | 2003-01-12 | 2003-06-12 |  | 0d |  |
| 76 | 4.1 | bestektekeningen |  | 3d | 2003-01-12 | 2003-01-14 |  | 0d |  |
| 77 | 4.2 | overzichtstekening natuursteen |  | 5d | 2003-01-15 | 2003-01-19 | 76 | 0d |  |
| 78 | 4.3 | principe details natuursteen |  | 5d | 2003-01-15 | 2003-01-19 | 77SS | 0d |  |

| ID | WBS | Task | Type | Duration | Start | Finish | Predecessors | Total slack | Free slack |
| --- | --- | --- | --- | --- | --- | --- | --- | --- | --- |
| 79 | 4.4 | **contractvorming** |  | 36d | 2003-01-20 | 2003-02-24 | 78 | 0d |  |
| 80 | 4.4.1 | prijsaanvraag opstellen |  | 5d | 2003-01-20 | 2003-01-24 |  | 0d |  |
| 81 | 4.4.2 | offerte aanvraag leveranciers |  | 5d | 2003-01-25 | 2003-01-29 | 80 | 0d |  |
| 82 | 4.4.3 | opstellen offerte door leveranciers |  | 10d | 2003-01-30 | 2003-02-08 | 81 | 0d |  |
| 83 | 4.4.4 | offertes leveranciers beoordelen |  | 5d | 2003-02-09 | 2003-02-13 | 82 | 0d |  |
| 84 | 4.4.5 | prijsonderhandeling met lev. |  | 5d | 2003-02-14 | 2003-02-18 | 83 | 0d |  |
| 85 | 4.4.6 | leveringscontract opstellen |  | 3d | 2003-02-19 | 2003-02-21 | 84 | 0d |  |
| 86 | 4.4.7 | leveringscontract tekenen |  | 3d | 2003-02-22 | 2003-02-24 | 85 | 0d |  |
| 87 | 4.5 | **productietekening natuursteen** |  | 58d | 2003-02-25 | 2003-04-23 |  | 0d |  |
| 88 | 4.5.1 | concept productietek.maken |  | 20d | 2003-02-25 | 2003-03-16 | 86 | 0d |  |
| 89 | 4.5.2 | controle tekening door partners |  | 20d | 2003-03-07 | 2003-03-26 | 88SS+10d | 0d |  |
| 90 | 4.5.3 | commentaar partners verwerken |  | 20d | 2003-03-17 | 2003-04-05 | 89SS+10d | 0d |  |
| 91 | 4.5.4 | productie.tek.definitief maken |  | 10d | 2003-04-01 | 2003-04-10 | 90SS+15d | 0d |  |
| 92 | 4.5.5 | controle prod.tek. door partners |  | 10d | 2003-04-11 | 2003-04-20 | 91 | 0d |  |
| 93 | 4.5.6 | productietekening goedkeuren |  | 3d | 2003-04-21 | 2003-04-23 | 92 | 0d |  |
| 94 | 4.6 | **productieproces natuursteen** |  | 50d | 2003-04-24 | 2003-06-12 | 93 | 0d |  |
| 95 | 4.6.1 | voorbereiding productie |  | 10d | 2003-04-24 | 2003-05-03 |  | 0d |  |
| 96 | 4.6.2 | produceren natuursteenplaten |  | 40d | 2003-05-04 | 2003-06-12 | 95 | 0d |  |
| 97 | 4.6.3 | afroepen 1e levering natuursteen |  | 1d | 2003-05-24 | 2003-05-24 | 96SS+20d | 10d | 0d |
| 98 | 4.6.4 | start montage natuursteen | milestone | 0d | 2003-06-02 | 2003-06-02 | 97SS+10d | 10d |  |
| 100 | 5 | **GLAS+VIDE DAKKAPPEN** |  | 142d | 2003-01-12 | 2003-06-02 |  | 10d |  |
| 101 | 5.1 | bestektekeningen |  | 3d | 2003-01-12 | 2003-01-14 |  | 10d | 0d |
| 102 | 5.2 | overzichtstekening glasdakkappen |  | 5d | 2003-01-15 | 2003-01-19 | 101 | 10d | 0d |
| 103 | 5.3 | principe details glasdakkappen |  | 5d | 2003-01-15 | 2003-01-19 | 102SS | 10d | 0d |

| ID | WBS | Task | Type | Duration | Start | Finish | Predecessors | Total slack | Free slack |
| --- | --- | --- | --- | --- | --- | --- | --- | --- | --- |
| 104 | 5.4 | **contractvorming** |  | 36d | 2003-01-20 | 2003-02-24 | 103 | 10d |  |
| 105 | 5.4.1 | prijsaanvraag opstellen |  | 5d | 2003-01-20 | 2003-01-24 |  | 10d | 0d |
| 106 | 5.4.2 | offerte aanvraag leveranciers |  | 5d | 2003-01-25 | 2003-01-29 | 105 | 10d | 0d |
| 107 | 5.4.3 | opstellen offerte door leveranciers |  | 10d | 2003-01-30 | 2003-02-08 | 106 | 10d | 0d |
| 108 | 5.4.4 | offertes leveranciers beoordelen |  | 5d | 2003-02-09 | 2003-02-13 | 107 | 10d | 0d |
| 109 | 5.4.5 | prijsonderhandeling met lev. |  | 5d | 2003-02-14 | 2003-02-18 | 108 | 10d | 0d |
| 110 | 5.4.6 | leveringscontract opstellen |  | 3d | 2003-02-19 | 2003-02-21 | 109 | 10d | 0d |
| 111 | 5.4.7 | leveringscontract tekenen |  | 3d | 2003-02-22 | 2003-02-24 | 110 | 10d | 0d |
| 112 | 5.5 | **productietek, glasdakkappen** |  | 58d | 2003-02-25 | 2003-04-23 |  | 10d |  |
| 113 | 5.5.1 | concept productietek.maken |  | 20d | 2003-02-25 | 2003-03-16 | 111 | 10d | 0d |
| 114 | 5.5.2 | controle tekening door partners |  | 20d | 2003-03-07 | 2003-03-26 | 113SS+10d | 10d | 0d |
| 115 | 5.5.3 | commentaar partners verwerken |  | 20d | 2003-03-17 | 2003-04-05 | 114SS+10d | 10d | 0d |
| 116 | 5.5.4 | productie.tek.definitief maken |  | 10d | 2003-04-01 | 2003-04-10 | 115SS+15d | 10d | 0d |
| 117 | 5.5.5 | controle prod.tek. door partners |  | 10d | 2003-04-11 | 2003-04-20 | 116 | 10d | 0d |
| 118 | 5.5.6 | productietekening goedkeuren |  | 3d | 2003-04-21 | 2003-04-23 | 117 | 10d | 0d |
| 119 | 5.6 | **productieproces glasdakkappen** |  | 40d | 2003-04-24 | 2003-06-02 | 118 | 10d |  |
| 120 | 5.6.1 | voorbereiding productie |  | 10d | 2003-04-24 | 2003-05-03 |  | 10d | 0d |
| 121 | 5.6.2 | produceren glasdakkappen |  | 30d | 2003-05-04 | 2003-06-02 | 120 | 10d | 0d |
| 122 | 5.6.3 | afroepen 1e levering glaskappen |  | 1d | 2003-05-24 | 2003-05-24 | 121SS+20d | 10d | 0d |
| 123 | 5.6.4 | start montage glasdakkappen | milestone | 0d | 2003-06-02 | 2003-06-02 | 122SS+10d | 10d |  |
| 125 | 6 | **AUTOM.+BEDRIJFSDEUREN** |  | 124d? | 2003-01-12 | 2003-05-15 |  | 28d |  |
| 126 | 6.1 | bestektekeningen |  | 3d | 2003-01-12 | 2003-01-14 |  | 28d | 0d |
| 127 | 6.2 | overzichtstekening autom,deuren |  | 5d | 2003-01-15 | 2003-01-19 | 126 | 28d | 0d |
| 128 | 6.3 | principe details autom,deuren |  | 5d | 2003-01-15 | 2003-01-19 | 127SS | 28d | 0d |

| ID | WBS | Task | Type | Duration | Start | Finish | Predecessors | Total slack | Free slack |
| --- | --- | --- | --- | --- | --- | --- | --- | --- | --- |
| 129 | 6.4 | **contractvorming** |  | 28d | 2003-01-20 | 2003-02-16 | 128 | 28d |  |
| 130 | 6.4.1 | prijsaanvraag opstellen |  | 3d | 2003-01-20 | 2003-01-22 |  | 28d | 0d |
| 131 | 6.4.2 | offerte aanvraag leveranciers |  | 3d | 2003-01-23 | 2003-01-25 | 130 | 28d | 0d |
| 132 | 6.4.3 | opstellen offerte door leveranciers |  | 10d | 2003-01-26 | 2003-02-04 | 131 | 28d | 0d |
| 133 | 6.4.4 | offertes leveranciers beoordelen |  | 3d | 2003-02-05 | 2003-02-07 | 132 | 28d | 0d |
| 134 | 6.4.5 | prijsonderhandeling met lev. |  | 5d | 2003-02-08 | 2003-02-12 | 133 | 28d | 0d |
| 135 | 6.4.6 | leveringscontract opstellen |  | 2d | 2003-02-13 | 2003-02-14 | 134 | 28d | 0d |
| 136 | 6.4.7 | leveringscontract tekenen |  | 2d | 2003-02-15 | 2003-02-16 | 135 | 28d | 0d |
| 137 | 6.5 | **productietek, autom+bedrijfsdeuren** |  | 48d | 2003-02-17 | 2003-04-05 |  | 28d |  |
| 138 | 6.5.1 | concept productietek.maken |  | 10d | 2003-02-17 | 2003-02-26 | 136 | 28d | 0d |
| 139 | 6.5.2 | controle tekening door partners |  | 10d | 2003-02-27 | 2003-03-08 | 138SS+10d | 28d | 0d |
| 140 | 6.5.3 | commentaar partners verwerken |  | 10d | 2003-03-09 | 2003-03-18 | 139SS+10d | 28d | 0d |
| 141 | 6.5.4 | productie.tek.definitief maken |  | 5d | 2003-03-19 | 2003-03-23 | 140SS+10d | 28d | 0d |
| 142 | 6.5.5 | controle prod.tek. door partners |  | 10d | 2003-03-24 | 2003-04-02 | 141 | 28d | 0d |
| 143 | 6.5.6 | productietekening goedkeuren |  | 3d | 2003-04-03 | 2003-04-05 | 142 | 28d | 0d |
| 144 | 6.6 | **productieproces autom,deuren** |  | 40d | 2003-04-06 | 2003-05-15 | 143 | 28d |  |
| 145 | 6.6.1 | voorbereiding productie |  | 10d | 2003-04-06 | 2003-04-15 |  | 28d | 0d |
| 146 | 6.6.2 | produceren autom, deuren |  | 30d | 2003-04-16 | 2003-05-15 | 145 | 28d | 0d |
| 147 | 6.6.3 | afroepen 1e levering autom.deuren |  | 1d | 2003-05-06 | 2003-05-06 | 146SS+20d | 28d | 0d |
| 148 | 6.6.4 | start montage autom, deuren | milestone | 0d | 2003-05-15 | 2003-05-15 | 147SS+10d | 28d |  |
